| id | name | startDate | endDate | priority | barScale | progress | type | parentId | dependencies |
| --- | --- | --- | --- | --- | --- | --- | --- | --- | --- |
| 1 | Reforma de vivienda | 2026-06-01T00:00:00.000Z | 2026-09-21T00:00:00.000Z | medium | 1 | 0 | group |  |  |
| 2 | Alcance y selección de acabados | 2026-06-01T00:00:00.000Z | 2026-06-15T00:00:00.000Z | high | 1 | 0 | task | 1 |  |
| 3 | Planos arquitectónicos | 2026-06-08T00:00:00.000Z | 2026-06-22T00:00:00.000Z | medium | 1 | 0 | task | 1 | 2 SS |
| 4 | Solicitud de permiso | 2026-06-22T00:00:00.000Z | 2026-06-23T00:00:00.000Z | medium | 1 | 0 | milestone | 1 | 3 FS |
| 5 | Revisión del permiso | 2026-06-22T00:00:00.000Z | 2026-07-13T00:00:00.000Z | medium | 1 | 0 | task | 1 | 4 FS |
| 6 | Pedido de materiales de plazo largo | 2026-06-15T00:00:00.000Z | 2026-06-22T00:00:00.000Z | high | 1 | 0 | task | 1 |  |
| 7 | Demolición | 2026-06-29T00:00:00.000Z | 2026-07-04T00:00:00.000Z | medium | 1 | 0 | task | 1 | 5 FS |
| 8 | Cambios de estructura | 2026-07-04T00:00:00.000Z | 2026-07-11T00:00:00.000Z | medium | 1 | 0 | task | 1 | 7 FS |
| 9 | Fontanería en bruto | 2026-07-11T00:00:00.000Z | 2026-07-16T00:00:00.000Z | medium | 1 | 0 | task | 1 | 8 FS |
| 10 | Electricidad en bruto | 2026-07-13T00:00:00.000Z | 2026-07-18T00:00:00.000Z | medium | 1 | 0 | task | 1 | 8 FS |
| 11 | Climatización en bruto | 2026-07-15T00:00:00.000Z | 2026-07-19T00:00:00.000Z | medium | 1 | 0 | task | 1 | 8 FS |
| 12 | Inspecciones en bruto | 2026-07-21T00:00:00.000Z | 2026-07-23T00:00:00.000Z | medium | 1 | 0 | milestone | 1 |  |
| 13 | Paneles de yeso | 2026-07-23T00:00:00.000Z | 2026-08-02T00:00:00.000Z | medium | 1 | 0 | task | 1 | 12 FS |
| 14 | Pintura | 2026-08-02T00:00:00.000Z | 2026-08-09T00:00:00.000Z | medium | 1 | 0 | task | 1 | 13 FS |
| 15 | Suelos | 2026-08-09T00:00:00.000Z | 2026-08-16T00:00:00.000Z | medium | 1 | 0 | task | 1 | 14 FS |
| 16 | Instalación de armarios | 2026-08-16T00:00:00.000Z | 2026-08-21T00:00:00.000Z | medium | 1 | 0 | task | 1 | 15 FS |
| 17 | Plantilla de encimera | 2026-08-21T00:00:00.000Z | 2026-08-22T00:00:00.000Z | medium | 1 | 0 | milestone | 1 | 16 FS |
| 18 | Instalación de encimera | 2026-08-31T00:00:00.000Z | 2026-09-02T00:00:00.000Z | medium | 1 | 0 | task | 1 | 17 FS |
| 19 | Fontanería e iluminación | 2026-09-02T00:00:00.000Z | 2026-09-09T00:00:00.000Z | medium | 1 | 0 | task | 1 |  |
| 20 | Lista de pendientes y cierre | 2026-09-09T00:00:00.000Z | 2026-09-21T00:00:00.000Z | medium | 1 | 0 | task | 1 |  |
